# BUS419 Assignment 2_MS Project Exercise

Schedule from MS Project, 2017-04-24 to 2017-07-26, costs in $.

## Calendars

- Standard: Mon-Fri 08:00-12:00, 13:00-17:00; Sat-Sun off.

## Resources

| Resource | Rate |
| --- | --- |
| John Doe (PM) | 105 |
| James Brown (SI) | 110 |
| Jane White (SI) | 85 |
| Bruce Green (IV&V Tester) | 80 |
| Wilma Ellis (IA) | 115 |
| Billy Bob (Ops) | 85 |

## Schedule

| ID | WBS | Task | Type | Duration | Start | Finish | Baseline start | Baseline finish | Baseline duration | Total slack | Constraint | Resources | Work | Cost | Baseline cost |
| --- | --- | --- | --- | --- | --- | --- | --- | --- | --- | --- | --- | --- | --- | --- | --- |
| 1 | 1 | **Windows 10 Enterprise Client v2.0.0.x** |  | 68d | 2017-04-24 | 2017-07-26 | 2017-04-24 | 2017-07-26 | 68d | 0d |  |  | 528h | 55,160 | 55,160 |
| 2 | 1.1 | **S/W Requirements** |  | 17d | 2017-04-24 | 2017-05-16 | 2017-04-24 | 2017-05-01 | 6d | 0d |  |  | 40h | 4,200 | 4,200 |
| 3 | 1.1.1 | **Requiremnent Definition Form (RDF)** |  | 17d | 2017-04-24 | 2017-05-16 | 2017-04-24 | 2017-05-01 | 6d | 0d |  |  | 40h | 4,200 | 4,200 |
| 4 | 1.1.1.1 | RDF Development | manual | 5d | 2017-04-24 | 2017-04-28 | 2017-04-24 | 2017-04-28 | 5d |  |  | John Doe (PM) | 40h | 4,200 | 4,200 |
| 5 | 1.1.1.2 | RDF Approval | manual | 2d | 2017-05-15 | 2017-05-16 | 2017-04-28 | 2017-05-01 | 2d |  |  |  |  |  |  |
| 6 | 1.2 | **Requirement Project Plan** |  | 14d | 2017-05-16 | 2017-06-02 | 2017-05-02 | 2017-05-18 | 13d | 0d |  |  | 120h | 12,360 | 12,360 |
| 7 | 1.2.1 | Draft plan and schedule | manual | 10d | 2017-05-22 | 2017-06-02 | 2017-05-02 | 2017-05-15 | 10d |  |  | John Doe (PM) | 80h | 8,400 | 8,400 |
| 8 | 1.2.2 | RPP Review Mtg | manual | 1d | 2017-05-16 | 2017-05-16 | 2017-05-16 | 2017-05-16 | 1d |  |  | Billy Bob (Ops); Bruce Green (IV&V Tester); James Brown (SI); John Doe (PM); Wilma Ellis (IA) | 40h | 3,960 | 3,960 |
| 9 | 1.2.3 | RPP Approval | manual | 2d | 2017-05-17 | 2017-05-18 | 2017-05-17 | 2017-05-18 | 2d |  |  |  |  |  |  |
| 10 | 1.3 | Software Delivery and Acceptance |  | 1d | 2017-05-29 | 2017-05-29 | 2017-05-29 | 2017-05-29 | 1d | 42d | start no earlier than 2017-05-29 | John Doe (PM) | 8h | 840 | 840 |
| 11 | 1.4 | **Software Integration** |  | 29d | 2017-05-30 | 2017-07-07 | 2017-05-30 | 2017-07-07 | 29d | 0d |  |  | 248h | 26,040 | 26,040 |
| 12 | 1.4.1 | **Integration** |  | 29d | 2017-05-30 | 2017-07-07 | 2017-05-30 | 2017-07-07 | 29d | 0d |  |  | 248h | 26,040 | 26,040 |
| 13 | 1.4.1.1 | **Integrate S/W & IP** |  | 18d | 2017-05-30 | 2017-06-22 | 2017-05-30 | 2017-06-22 | 18d | 0d |  |  | 144h | 15,640 | 15,640 |
| 14 | 1.4.1.1.1 | Acquire Software components | manual | 1d | 2017-05-30 | 2017-05-30 | 2017-05-30 | 2017-05-30 | 1d |  |  | James Brown (SI) | 8h | 880 | 880 |
| 15 | 1.4.1.1.2 | Acquire Patches | manual | 2d | 2017-05-31 | 2017-06-01 | 2017-05-31 | 2017-06-01 | 2d |  |  | James Brown (SI) | 16h | 1,760 | 1,760 |
| 16 | 1.4.1.1.3 | Integrate SW | manual | 9d | 2017-06-02 | 2017-06-14 | 2017-06-02 | 2017-06-14 | 9d |  |  | James Brown (SI) | 72h | 7,920 | 7,920 |
| 17 | 1.4.1.1.4 | Implement Security Requirements | manual | 5d | 2017-06-15 | 2017-06-21 | 2017-06-15 | 2017-06-21 | 5d |  |  | James Brown (SI) | 40h | 4,400 | 4,400 |
| 18 | 1.4.1.1.5 | Peer Test | manual | 1d | 2017-06-22 | 2017-06-22 | 2017-06-22 | 2017-06-22 | 1d |  |  | Jane White (SI) | 8h | 680 | 680 |
| 19 | 1.4.1.2 | **Software Qualification Assurance** |  | 11d | 2017-06-23 | 2017-07-07 | 2017-06-23 | 2017-07-07 | 11d | 0d |  |  | 104h | 10,400 | 10,400 |
| 20 | 1.4.1.2.1 | **IV&V Testing** |  | 3d | 2017-06-23 | 2017-06-27 | 2017-06-23 | 2017-06-27 | 3d | 0d |  |  | 24h | 1,920 | 1,920 |
| 21 | 1.4.1.2.1.1 | Installation Procedures Test | manual | 2d | 2017-06-23 | 2017-06-26 | 2017-06-23 | 2017-06-26 | 2d |  |  | Bruce Green (IV&V Tester) | 16h | 1,280 | 1,280 |
| 22 | 1.4.1.2.1.2 | Functionality Test | manual | 1d | 2017-06-27 | 2017-06-27 | 2017-06-27 | 2017-06-27 | 1d |  |  | Bruce Green (IV&V Tester) | 8h | 640 | 640 |
| 23 | 1.4.1.2.2 | **Security Testing** |  | 7d | 2017-06-23 | 2017-07-03 | 2017-06-23 | 2017-07-03 | 7d | 0d |  |  | 56h | 6,440 | 6,440 |
| 24 | 1.4.1.2.2.1 | Compliance and Vulnerability Testing | manual | 2d | 2017-06-23 | 2017-06-26 | 2017-06-23 | 2017-06-26 | 2d |  |  | Wilma Ellis (IA) | 16h | 1,840 | 1,840 |
| 25 | 1.4.1.2.2.2 | Update Security Documentation | manual | 5d | 2017-06-27 | 2017-07-03 | 2017-06-27 | 2017-07-03 | 5d |  |  | Wilma Ellis (IA) | 40h | 4,600 | 4,600 |

| ID | WBS | Task | Type | Duration | Start | Finish | Predecessors | Baseline start | Baseline finish | Baseline duration | Total slack | Resources | Work | Cost | Baseline cost |
| --- | --- | --- | --- | --- | --- | --- | --- | --- | --- | --- | --- | --- | --- | --- | --- |
| 26 | 1.4.1.2.3 | **Operations Evaluation** |  | 3d | 2017-07-05 | 2017-07-07 |  | 2017-07-05 | 2017-07-07 | 3d | 0d |  | 24h | 2,040 | 2,040 |
| 27 | 1.4.1.2.3.1 | Installation Procedures Test | manual | 2d | 2017-07-05 | 2017-07-06 |  | 2017-07-05 | 2017-07-06 | 2d |  | Billy Bob (Ops) | 16h | 1,360 | 1,360 |
| 28 | 1.4.1.2.3.2 | Functionality Test | manual | 1d | 2017-07-07 | 2017-07-07 |  | 2017-07-07 | 2017-07-07 | 1d |  | Billy Bob (Ops) | 8h | 680 | 680 |
| 29 | 1.5 | **Accreditation Process** |  | 13d | 2017-07-10 | 2017-07-26 |  | 2017-07-10 | 2017-07-26 | 13d | 0d |  | 112h | 11,720 | 11,720 |
| 30 | 1.5.1 | Test Planning Meeting | manual | 1d | 2017-07-10 | 2017-07-10 | 28 | 2017-07-10 | 2017-07-10 | 1d |  | John Doe (PM); Wilma Ellis (IA) | 16h | 1,760 | 1,760 |
| 31 | 1.5.2 | Test Events | manual | 3d | 2017-07-24 | 2017-07-26 |  | 2017-07-24 | 2017-07-26 | 3d |  | Billy Bob (Ops); James Brown (SI); John Doe (PM); Wilma Ellis (IA) | 96h | 9,960 | 9,960 |
